# Projet M et Mme Duval

Schedule from GanttProject, 2023-09-11 to 2024-02-15.
Holidays every year on 01-01, 05-01, 05-08, 07-14, 08-15, 11-01, 11-11, 12-25

## Calendars

- Project calendar: Mon-Fri working; Sat-Sun off.

## Resources

| Resource |
| --- |
| ABC du Bâtiment |
| Energie Futura |
| Menuiserie Rossi |
| Acrylcolor |
| Cuisines Larippe |
| Clients |
| Rêv'L |

## Schedule

| ID | WBS | Task | Duration | Start | Finish | Predecessors | Constraint | Resources |
| --- | --- | --- | --- | --- | --- | --- | --- | --- |
| 1 | 1 | **PREALABLE** | 1d | 2023-09-29 | 2023-09-29 |  |  |  |
| 2 | 1.1 | Dépose des meubles à conserver dans la cuisine par les clients | 1d | 2023-09-29 | 2023-09-29 |  |  | Clients |
| 3 | 1.2 | Désactivation de l'alarme dans la zone de travaux et dépose des détecteurs | 1d | 2023-09-29 | 2023-09-29 |  |  | Clients |
| 4 | 2 | **MISE EN SECURITE** | 2d | 2023-10-02 | 2023-10-03 |  |  | Clients |
| 5 | 2.1 | Dépose radiateurs / WC / lave-mains + mise en sécurité réseaux sanitaires | 2d | 2023-10-02 | 2023-10-03 |  |  | Energie Futura |
| 6 | 2.2 | Mise en sécurité électrique / VMC / débranchement électroménager | 2d | 2023-10-02 | 2023-10-03 |  |  | Energie Futura |
| 7 | 3 | **MENUISERIES EXTERIEURES** | 31d | 2023-09-11 | 2023-10-23 |  |  |  |
| 8 | 3.1 | Commande VR et fabrication de la porte extérieure cuisine | 30d | 2023-09-11 | 2023-10-20 |  |  | Menuiserie Rossi |
| 9 | 3.2 | DéposeDépose et pose porte extérieure de la cuisine et des volets | 1d | 2023-10-23 | 2023-10-23 | 3, 8 |  | Menuiserie Rossi |
| 10 | 4 | **DEPOSE / DEMOLITION** | 11d | 2023-10-03 | 2023-10-17 |  |  |  |
| 11 | 4.1 | Dépose et conservation de la plaque de cuisson | 1d | 2023-10-04 | 2023-10-04 | 6 |  | Clients |
| 12 | 4.2 | Dépose Menuiserie intérieure | 1d | 2023-10-03 | 2023-10-03 |  |  | Menuiserie Rossi |
| 13 | 4.3 | Dépose Maçonnerie | 10d | 2023-10-04 | 2023-10-17 | 2, 4, 5, 6, 12 |  | ABC du Bâtiment |
| 14 | 5 | Dépose et conservation de la plaque de cuisson | 1d | 2023-10-04 | 2023-10-04 |  |  | Clients |
| 15 | 6 | MACONNERIE PENTE | 1d | 2023-10-18 | 2023-10-18 | 13 |  | ABC du Bâtiment |
| 16 | 7 | **PASSAGE DES RESEAUX ELECTRIQUES ET SANITAIRES** | 19d | 2023-10-23 | 2023-11-17 |  |  | Energie Futura |
| 17 | 7.1 | Reprise boitier électrique + percements réseaux murs/plafonds | 5d | 2023-10-23 | 2023-10-27 | 13 | start no earlier than 2023-10-23 | Energie Futura |
| 18 | 7.2 | Positionnement radiateurs pour repérage + Passage des câbles et réseaux électriques | 3d | 2023-11-15 | 2023-11-17 | 22 |  | Energie Futura |
| 19 | 7.3 | Passage des réseaux sanitaires sols/murs + pose bâti support | 3d | 2023-11-15 | 2023-11-17 | 22 |  | Energie Futura |
| 20 | 8 | **RAILAGE / PLACO** | 17d | 2023-11-02 | 2023-11-24 |  |  |  |
| 21 | 8.1 | Railage plafond/doublages | 6d | 2023-11-02 | 2023-11-09 | 26 |  | ABC du Bâtiment |
| 22 | 8.2 | Railage cloisons intérieures | 2d | 2023-11-13 | 2023-11-14 | 41 |  | ABC du Bâtiment |
| 23 | 8.3 | Pose isolation + placo | 3d | 2023-11-20 | 2023-11-22 | 18, 19 |  |  |
| 24 | 8.4 | Bandes placo | 2d | 2023-11-23 | 2023-11-24 | 23 |  | ABC du Bâtiment |

| ID | WBS | Task | Duration | Start | Finish | Predecessors | Constraint | Resources |
| --- | --- | --- | --- | --- | --- | --- | --- | --- |
| 25 | 9 | **REPRISE MENUISERIES INTERIEURES** | 2d | 2023-10-30 | 2023-10-31 |  |  |  |
| 26 | 9.1 | Reprise plafond rampant / lames sol | 2d | 2023-10-30 | 2023-10-31 | 13, 17 |  | Menuiserie Rossi |
| 27 | 10 | **POSE CARRELAGE** | 24d | 2023-10-27 | 2023-11-30 |  |  |  |
| 28 | 10.1 | Commande carreaux | 15d | 2023-10-27 | 2023-11-17 |  |  |  |
| 29 | 10.2 | Pose du carrelage en fond de niche de la cuisine | 1d | 2023-11-28 | 2023-11-28 | 24, 28 | start no earlier than 2023-11-28 | ABC du Bâtiment |
| 30 | 10.3 | Pose du carrelage sur le mur du WC | 2d | 2023-11-29 | 2023-11-30 | 24, 28, 29 |  | ABC du Bâtiment |
| 31 | 11 | **FABRICATION AGENCEMENT / MENUSERIES INTERIEURES** | 70d | 2023-10-04 | 2024-01-12 |  |  | Menuiserie Rossi |
| 32 | 11.1 | Modification porte intérieure + fabication placard tableau / plinthes / dormant dressing | 5d | 2023-10-04 | 2023-10-10 | 12 |  | Menuiserie Rossi |
| 33 | 11.2 | Prises de cotes définitives pour la fabrication des agencements sur mesure | 1d | 2023-11-27 | 2023-11-27 | 24 |  | Menuiserie Rossi |
| 34 | 11.3 | Fabrication dressing | 28d | 2023-12-04 | 2024-01-12 | 33, 42 |  | Menuiserie Rossi |
| 35 | 12 | **PREPARATION ET POSE REVETEMENTS MURAUX** | 56d | 2023-11-27 | 2024-02-14 |  |  | Acrylcolor |
| 36 | 12.1 | Commande papier-peint | 10d | 2023-11-27 | 2023-12-08 | 24 |  | Acrylcolor |
| 37 | 12.2 | Préparation, grattage, peinture des murs/plafonds/boiseries + pose PP | 10d | 2023-12-11 | 2023-12-22 | 24, 36, 46 |  | Acrylcolor |
| 38 | 12.3 | Finitions / reprises peinture si nécessaire | 2d | 2024-02-13 | 2024-02-14 | 53, 58 |  | Acrylcolor |
| 39 | 13 | **POSE AGENCEMENT / MENUISERIES INTERIEURES** | 57d | 2023-10-30 | 2024-01-19 |  |  |  |
| 40 | 13.1 | Installation caisson et tablettes placard tableau | 2d | 2023-10-30 | 2023-10-31 | 17, 32 |  | Menuiserie Rossi |
| 41 | 13.2 | Pose montant appui 2 placards dressing | 1d | 2023-11-10 | 2023-11-10 | 21 |  | Menuiserie Rossi |
| 42 | 13.3 | Pose plinthes | 5d | 2023-11-27 | 2023-12-01 | 24, 32 |  | Menuiserie Rossi |
| 43 | 13.4 | Pose menuiseries intérieures | 3d | 2023-12-11 | 2023-12-13 | 1, 46 |  | Menuiserie Rossi |
| 44 | 13.5 | Pose agencement sur mesure | 5d | 2024-01-15 | 2024-01-19 | 34, 48 |  | Menuiserie Rossi |
| 45 | 14 | **PREPARATION ET POSE SOL** | 23d | 2023-12-04 | 2024-01-05 |  |  | Acrylcolor |
| 46 | 14.1 | Prépa sol + Ragréage fibré | 5d | 2023-12-04 | 2023-12-08 | 42 |  | Acrylcolor |
| 47 | 14.2 | Commande revêtement sol | 10d | 2023-12-11 | 2023-12-22 | 46 |  | Acrylcolor |
| 48 | 14.3 | Pose lino + baguette sol | 2d | 2024-01-04 | 2024-01-05 | 47, 55 | start no earlier than 2024-01-04 | Acrylcolor |

| ID | WBS | Task | Type | Duration | Start | Finish | Predecessors | Constraint | Resources |
| --- | --- | --- | --- | --- | --- | --- | --- | --- | --- |
| 49 | 15 | **POSE CUISINE** |  | 96d | 2023-09-25 | 2024-02-08 |  |  | Cuisines Larippe |
| 50 | 15.1 | Commande meubles cuisines + électroménager |  | 44d | 2023-09-25 | 2023-11-24 |  |  | Cuisines Larippe |
| 51 | 15.2 | Pose meubles + électroménager + prises de cotes plans |  | 3d | 2024-01-08 | 2024-01-10 | 37, 48 |  | Cuisines Larippe |
| 52 | 15.3 | Commande plan de travail |  | 20d | 2024-01-11 | 2024-02-07 | 51 |  | Cuisines Larippe |
| 53 | 15.4 | Pose plans de travail et crédences |  | 1d | 2024-02-08 | 2024-02-08 | 52 |  | Cuisines Larippe |
| 54 | 16 | **RACCORDEMENTS ET FINITIONS ELEC ET SANITAIRES** |  | 45d | 2023-12-11 | 2024-02-13 |  |  | Energie Futura |
| 55 | 16.1 | Pose et raccordements WC, lave-main, radiateurs |  | 1d | 2024-01-02 | 2024-01-02 | 46 | start no earlier than 2024-01-02 | Energie Futura |
| 56 | 16.2 | Raccordement éléments de cuisine |  | 1d | 2024-02-13 | 2024-02-13 | 51, 58 |  | Energie Futura |
| 57 | 16.3 | Pose des finitions électriques (boitiers et appareillage) |  | 4d | 2023-12-11 | 2023-12-14 | 46 |  | Energie Futura |
| 58 | 16.4 | Pose interrupteurs, prises, plafonniers, .... |  | 2d | 2024-02-09 | 2024-02-12 | 43, 44, 53, 57 |  | Energie Futura |
| 59 | 17 | **MISE EN SERVICE** |  | 1d | 2024-02-15 | 2024-02-15 |  |  |  |
| 60 | 17.1 | Mise en service Elec / VMC / Sanitaire / PAC |  | 1d | 2024-02-15 | 2024-02-15 | 38, 56, 58 |  | Energie Futura |
| 61 | 18 | REUNIONS DE CHANTIER | milestone | 0d | 2023-10-05 | 2023-10-05 |  | start no earlier than 2023-10-05 | ABC du Bâtiment; Energie Futura; Menuiserie Rossi; Acrylcolor; Cuisines Larippe; Clients; Rêv'L |
| 62 | 19 | ABSENCE CLIENTS |  | 5d | 2023-11-20 | 2023-11-24 |  |  |  |
